# ísimo

Schedule from MS Project, 2026-05-11 to 2026-06-19, status date 2026-06-07, A marks actual dates.

## Calendars

- Estándar: Mon-Fri 09:00-13:00, 15:00-19:00; Sat-Sun off.

## Schedule

| ID | WBS | Task | Duration | Start | Finish | Predecessors | Complete | Remaining | Baseline start | Baseline finish | Baseline duration | Total slack |
| --- | --- | --- | --- | --- | --- | --- | --- | --- | --- | --- | --- | --- |
| 1 | 1 | Optimización de los controles operativos y la trazabilidad del inventario en el CEDI regional costa de Tiendas Ísimo. | 1d | 2026-05-11 A | 2026-05-11 A |  | 100% |  | 2026-05-11 | 2026-05-11 | 1d |  |
| 2 | 2 | **ACTA DE CONSTITUCIÓN** | 2.5d | 2026-05-11 A | 2026-05-13 |  | 90% | 0.25d | 2026-05-11 | 2026-05-15 | 5d | 27.5d |
| 3 | 2.1 | **Documento de Definición del Problema** | 1d | 2026-05-11 A | 2026-05-11 A |  | 100% |  | 2026-05-11 | 2026-05-12 | 2d |  |
| 4 | 2.1.1 | • Investigar antecedentes de la gestión de inventarios en Tiendas Ísimo. | 1d | 2026-05-11 A | 2026-05-11 A |  | 100% |  |  |  |  |  |
| 5 | 2.1.2 | • Redactar el planteamiento del problema y formular la pregunta de investigación. | 1d | 2026-05-11 A | 2026-05-11 A |  | 100% |  |  |  |  |  |
| 6 | 2.2 | **Identificación de Stakeholders** | 1d | 2026-05-12 A | 2026-05-12 A | 3 | 100% |  | 2026-05-13 | 2026-05-14 | 2d |  |
| 7 | 2.2.1 | • Mapear los actores internos y externos del CEDI Costa. | 1d | 2026-05-12 A | 2026-05-12 A |  | 100% |  |  |  |  |  |
| 8 | 2.2.2 | • Clasificar el nivel de poder e interés de cada interesado. | 1d | 2026-05-12 A | 2026-05-12 A |  | 100% |  |  |  |  |  |
| 9 | 2.3 | **Acta de Constitución Aprobada** | 0.5d | 2026-05-13 A | 2026-05-13 | 6 | 50% | 0.25d | 2026-05-15 | 2026-05-15 | 1d | 27.5d |
| 10 | 2.3.1 | • Redactar el borrador del Acta de Constitución del proyecto. | 0.5d | 2026-05-13 A | 2026-05-13 A |  | 100% |  |  |  |  |  |
| 11 | 2.3.2 | • Socializar el documento y recolectar las firmas de aprobación. | 0.5d | 2026-05-13 | 2026-05-13 |  |  |  |  |  |  | 27.5d |
| 12 | 3 | **DIAGNÓSTICO DE LA SITUACIÓN ACTUAL** | 6d | 2026-05-13 A | 2026-05-21 A |  | 100% |  | 2026-05-18 | 2026-05-29 | 10d |  |
| 13 | 3.1 | **Informe de Exactitud de Inventarios (Actual)** | 2d | 2026-05-13 A | 2026-05-15 A | 9 | 100% |  | 2026-05-18 | 2026-05-21 | 4d |  |
| 14 | 3.1.1 | • Extraer la data histórica del sistema WMS del CEDI. | 2d | 2026-05-13 A | 2026-05-15 A |  | 100% |  |  |  |  |  |
| 15 | 3.1.2 | • Calcular el indicador ERI base (75%) y graficar las tendencias temporales. | 2d | 2026-05-13 A | 2026-05-15 A |  | 100% |  |  |  |  |  |
| 16 | 3.2 | **Informe de Discrepancias** | 2d | 2026-05-15 A | 2026-05-19 A | 13 | 100% |  | 2026-05-22 | 2026-05-26 | 3d |  |
| 17 | 3.2.1 | • Clasificar las inconsistencias por tipo de error en el muelle. | 1d | 2026-05-15 A | 2026-05-18 A |  | 100% |  |  |  |  |  |
| 18 | 3.2.2 | • Tabular los datos de faltantes y sobrantes identificados en campo. | 2d | 2026-05-15 A | 2026-05-19 A |  | 100% |  |  |  |  |  |
| 19 | 3.3 | **Informe de Pérdidas por Merma** | 2d | 2026-05-19 A | 2026-05-21 A | 16 | 100% |  | 2026-05-27 | 2026-05-29 | 3d |  |
| 20 | 3.3.1 | • Cruzar los datos de mermas con los valores de costos contables. | 1d | 2026-05-19 A | 2026-05-20 A |  | 100% |  |  |  |  |  |
| 21 | 3.3.2 | • Consolidar el impacto financiero acumulado ($12.3 millones de pesos COP). | 2d | 2026-05-19 A | 2026-05-21 A |  | 100% |  |  |  |  |  |
| 22 | 4 | **CARACTERIZACIÓN DE PROCESOS LOGÍSTICOS** | 4d | 2026-05-21 | 2026-05-27 |  |  |  | 2026-06-01 | 2026-06-10 | 8d | 0d |
| 23 | 4.1 | **Mapa Proceso de Recepción** | 1d | 2026-05-21 | 2026-05-22 | 19 |  |  | 2026-06-01 | 2026-06-02 | 2d | 0d |
| 24 | 4.1.1 | • Observar las tareas en el muelle de descarga de proveedores. | 1d | 2026-05-21 | 2026-05-22 |  |  |  |  |  |  | 0d |
| 25 | 4.1.2 | • Diagramar el flujo físico y lógico actual de la recepción. | 1d | 2026-05-21 | 2026-05-22 |  |  |  |  |  |  | 0d |

| ID | WBS | Task | Duration | Start | Finish | Predecessors | Baseline start | Baseline finish | Baseline duration | Total slack |
| --- | --- | --- | --- | --- | --- | --- | --- | --- | --- | --- |
| 26 | 4.2 | **Mapa Proceso Almacenamiento** | 1d | 2026-05-22 | 2026-05-25 | 23 | 2026-06-03 | 2026-06-04 | 2d | 0d |
| 27 | 4.2.1 | • Rastrear el traslado de mercancías hacia las estanterías (Put-away). | 1d | 2026-05-22 | 2026-05-25 |  |  |  |  | 0d |
| 28 | 4.2.2 | • Mapear los tiempos de desfase en la actualización del WMS. | 1d | 2026-05-22 | 2026-05-25 |  |  |  |  | 0d |
| 29 | 4.3 | **Mapa Proceso Picking** | 1d | 2026-05-25 | 2026-05-26 | 26 | 2026-06-05 | 2026-06-08 | 2d | 0d |
| 30 | 4.3.1 | • Acompañar a los operarios durante el alistamiento de pedidos. | 1d | 2026-05-25 | 2026-05-26 |  |  |  |  | 0d |
| 31 | 4.3.2 | • Registrar los cuellos de botella en la recolección de productos. | 1d | 2026-05-25 | 2026-05-26 |  |  |  |  | 0d |
| 32 | 4.4 | **Mapa Proceso Despacho** | 1d | 2026-05-26 | 2026-05-27 | 29 | 2026-06-09 | 2026-06-10 | 2d | 0d |
| 33 | 4.4.1 | • Analizar el control final antes de cargar los vehículos de reparto. | 1d | 2026-05-26 | 2026-05-27 |  |  |  |  | 0d |
| 34 | 4.4.2 | • Identificar las falencias en la transferencia de custodia de la carga. | 1d | 2026-05-26 | 2026-05-27 |  |  |  |  | 0d |
| 35 | 5 | **SISTEMA DE REGISTRO Y CONTROL DE DISCREPANCIAS** | 5d | 2026-05-27 | 2026-06-03 |  | 2026-06-11 | 2026-06-22 | 8d | 0d |
| 36 | 5.1 | **Matriz de Registro Discrepancias Diseñada** | 2d | 2026-05-27 | 2026-05-29 | 32 | 2026-06-11 | 2026-06-15 | 3d | 0d |
| 37 | 5.1.1 | • Estructurar los campos lógicos necesarios para registrar novedades. | 1d | 2026-05-27 | 2026-05-28 |  |  |  |  | 1d |
| 38 | 5.1.2 | • Diseñar una interfaz limpia y usable para el personal en muelle. | 2d | 2026-05-27 | 2026-05-29 |  |  |  |  | 0d |
| 39 | 5.2 | **Base de Datos Diferencias** | 2d | 2026-05-29 | 2026-06-02 | 36 | 2026-06-16 | 2026-06-18 | 3d | 0d |
| 40 | 5.2.1 | • Crear las tablas relacionales para el almacenamiento de registros. | 1d | 2026-05-29 | 2026-06-01 |  |  |  |  | 1d |
| 41 | 5.2.2 | • Programar las macros o fórmulas de validación en la base de datos. | 2d | 2026-05-29 | 2026-06-02 |  |  |  |  | 0d |
| 42 | 5.3 | **Reporte de Clasificación Logísticos** | 1d | 2026-06-02 | 2026-06-03 | 39 | 2026-06-19 | 2026-06-22 | 2d | 0d |
| 43 | 5.3.1 | • Definir el menú desplegable con las categorías estandarizadas de error. | 1d | 2026-06-02 | 2026-06-03 |  |  |  |  | 0d |
| 44 | 5.3.2 | • Validar la velocidad de carga del módulo de registro con pruebas piloto. | 1d | 2026-06-02 | 2026-06-03 |  |  |  |  | 0d |
| 45 | 6 | **MODELO DE CONTROL DE INVENTARIOS** | 4d | 2026-06-03 | 2026-06-09 |  | 2026-06-23 | 2026-07-01 | 7d | 0d |
| 46 | 6.1 | **Protocolo de Discrepancias Diseñada** | 2d | 2026-06-03 | 2026-06-05 | 42 | 2026-06-23 | 2026-06-25 | 3d | 0d |
| 47 | 6.1.1 | • Redactar los lineamientos operativos de acción ante descuadres de inventario. | 2d | 2026-06-03 | 2026-06-05 |  |  |  |  | 0d |
| 48 | 6.1.2 | • Definir los márgenes de tolerancia permitidos para los SKUs. | 1d | 2026-06-03 | 2026-06-04 |  |  |  |  | 1d |
| 49 | 6.2 | **Base de Datos Diferencias** | 1d | 2026-06-05 | 2026-06-08 | 46 | 2026-06-26 | 2026-06-29 | 2d | 0d |
| 50 | 6.2.1 | • Vincular el repositorio central de inventarios con los reportes diarios. | 1d | 2026-06-05 | 2026-06-08 |  |  |  |  | 0d |
| 51 | 6.2.2 | • Ejecutar pruebas de integridad referencial de los datos. | 1d | 2026-06-05 | 2026-06-08 |  |  |  |  | 0d |

| ID | WBS | Task | Duration | Start | Finish | Predecessors | Baseline start | Baseline finish | Baseline duration | Total slack |
| --- | --- | --- | --- | --- | --- | --- | --- | --- | --- | --- |
| 52 | 6.3 | **Indicadores de control Logísticos** | 1d | 2026-06-08 | 2026-06-09 | 49 | 2026-06-30 | 2026-07-01 | 2d | 0d |
| 53 | 6.3.1 | • Diseñar el modelo de datos dinámico en Power BI Desktop. | 1d | 2026-06-08 | 2026-06-09 |  |  |  |  | 0d |
| 54 | 6.3.2 | • Programar las alertas visuales automáticas para los KPIs de control (ERI/ERU). | 1d | 2026-06-08 | 2026-06-09 |  |  |  |  | 0d |
| 55 | 7 | **SISTEMA DE TRAZABILIDAD LOGÍSTICA** | 3d | 2026-06-09 | 2026-06-12 |  | 2026-07-02 | 2026-07-09 | 6d | 0d |
| 56 | 7.1 | **Ficha de Caracterización (SIPOC)** | 1d | 2026-06-09 | 2026-06-10 | 52 | 2026-07-02 | 2026-07-03 | 2d | 0d |
| 57 | 7.1.1 | • Estructurar las tablas SIPOC para cada nodo del CEDI Costa. | 1d | 2026-06-09 | 2026-06-10 |  |  |  |  | 0d |
| 58 | 7.1.2 | • Formalizar los proveedores, entradas, salidas y clientes por proceso. | 1d | 2026-06-09 | 2026-06-10 |  |  |  |  | 0d |
| 59 | 7.2 | **Puntos Críticos de Control (PCC)** | 1d | 2026-06-10 | 2026-06-11 | 56 | 2026-07-06 | 2026-07-07 | 2d | 0d |
| 60 | 7.2.1 | • Determinar las zonas de la bodega con mayor riesgo de pérdida de trazabilidad. | 1d | 2026-06-10 | 2026-06-11 |  |  |  |  | 0d |
| 61 | 7.2.2 | • Establecer los métodos de auditoría periódica para cada punto crítico. | 1d | 2026-06-10 | 2026-06-11 |  |  |  |  | 0d |
| 62 | 7.3 | **Flujo de Trazabilidad Diseñado** | 1d | 2026-06-11 | 2026-06-12 | 59 | 2026-07-08 | 2026-07-09 | 2d | 0d |
| 63 | 7.3.1 | • Diseñar los canales de comunicación obligatorios con el transporte 3PL. | 1d | 2026-06-11 | 2026-06-12 |  |  |  |  | 0d |
| 64 | 7.3.2 | • Documentar el flujo integrado de información y custodia física. | 1d | 2026-06-11 | 2026-06-12 |  |  |  |  | 0d |
| 65 | 8 | **INFORME DE ANÁLISIS Y VALIDACIÓN** | 3.5d | 2026-06-12 | 2026-06-17 |  | 2026-07-10 | 2026-07-17 | 6d | 0d |
| 66 | 8.1 | **Informe de Análisis Estadístico Discrepancias** | 2d | 2026-06-12 | 2026-06-16 | 62 | 2026-07-10 | 2026-07-14 | 3d | 0d |
| 67 | 8.1.1 | • Ejecutar análisis de frecuencias y diagramas de Pareto con los datos de errores. | 2d | 2026-06-12 | 2026-06-16 |  |  |  |  | 0d |
| 68 | 8.1.2 | • Redactar las interpretaciones analíticas de los resultados estadísticos. | 1d | 2026-06-12 | 2026-06-15 |  |  |  |  | 1d |
| 69 | 8.2 | **Informe de Identificación de Causas Raíz** | 1d | 2026-06-16 | 2026-06-17 | 66 | 2026-07-15 | 2026-07-16 | 2d | 0d |
| 70 | 8.2.1 | • Desarrollar el análisis de causas raíz mediante diagramas de Ishikawa o Árboles lógicos. | 1d | 2026-06-16 | 2026-06-17 |  |  |  |  | 0d |
| 71 | 8.2.2 | • Conectar las causas operativas con el diseño final de la propuesta MCOTL. | 1d | 2026-06-16 | 2026-06-17 |  |  |  |  | 0d |
| 72 | 8.3 | **Acta de Cierre del Proyecto** | 0.5d | 2026-06-17 | 2026-06-17 | 69 | 2026-07-17 | 2026-07-17 | 1d | 0d |
| 73 | 8.3.1 | • Compilar la documentación de soporte y lecciones aprendidas. | 0.5d | 2026-06-17 | 2026-06-17 |  |  |  |  | 0d |
| 74 | 8.3.2 | • Gestionar la firma de aceptación final por parte de la Jefatura de Inventarios. | 0.5d | 2026-06-17 | 2026-06-17 |  |  |  |  | 0d |
| 75 | 9 | **DOCUMENTO FINAL DEL PROYECTO** | 30d? | 2026-05-11 | 2026-06-19 |  | 2026-07-20 | 2026-07-23 | 4d | 0d |
| 76 | 9.1 | **Informe Final del Proyecto** | 1d | 2026-06-18 | 2026-06-18 | 72 | 2026-07-20 | 2026-07-21 | 2d | 0d |
| 77 | 9.1.1 | • Unificar los capítulos analíticos, metodológicos y de diseño en el documento maestro. | 1d | 2026-06-18 | 2026-06-18 |  |  |  |  | 0d |

| ID | WBS | Task | Duration | Start | Finish | Predecessors | Baseline start | Baseline finish | Baseline duration | Total slack |
| --- | --- | --- | --- | --- | --- | --- | --- | --- | --- | --- |
| 78 | 9.2 | **Documento del Proyecto** | 1d | 2026-06-19 | 2026-06-19 | 76 | 2026-07-22 | 2026-07-23 | 2d | 0d |
| 79 | 9.2.1 | • Organizar los manuales SIPOC independientes y las herramientas digitales. | 1d | 2026-06-19 | 2026-06-19 |  |  |  |  | 0d |
| 80 | 9.3 | **Informe Final del Proyecto** | 1d? | 2026-05-11 | 2026-05-11 |  |  |  |  | 29d |
| 81 | 9.3.1 | • Diseñar las diapositivas ejecutivas para la presentación a los patrocinadores | 1d? | 2026-05-11 | 2026-05-11 |  |  |  |  | 29d |
| 82 | 9.3.2 | • Desarrollar simulacros de sustentación controlando los tiempos de presentación. | 1d? | 2026-05-11 | 2026-05-11 |  |  |  |  | 29d |
